# Software Development

Schedule from MS Project, 2002-10-07 to 2003-02-05, status date 2002-11-22, A marks actual dates.

## Calendars

- Standard: Mon-Fri 08:00-12:00, 13:00-17:00; Sat-Sun off.

## Resources

| Resource |
| --- |
| Management |
| Project Manager |
| Analyst |
| Developer |
| Testers |
| Trainers |
| Technical Communicators |
| Deployment Team |

## Schedule

| ID | WBS | Task | Type | Duration | Start | Finish | Predecessors | Complete | Remaining | Baseline start | Baseline finish | Baseline duration | Total slack | Free slack | Resources | Work | Actual work |
| --- | --- | --- | --- | --- | --- | --- | --- | --- | --- | --- | --- | --- | --- | --- | --- | --- | --- |
| 1 | 1 | **Scope** |  | 3.5d | 2002-10-07 A | 2002-10-10 A |  | 100% |  | 2002-10-07 | 2002-10-10 | 3.5d |  |  |  | 28h | 28h |
| 2 | 1.1 | Determine project scope |  | 4h | 2002-10-07 A | 2002-10-07 A |  | 100% |  | 2002-10-07 | 2002-10-07 | 4h |  |  | Management | 4h | 4h |
| 3 | 1.2 | Secure project sponsorship |  | 1d | 2002-10-07 A | 2002-10-08 A | 2 | 100% |  | 2002-10-07 | 2002-10-08 | 1d |  |  | Management | 8h | 8h |
| 4 | 1.3 | Define preliminary resources |  | 1d | 2002-10-08 A | 2002-10-09 A | 3 | 100% |  | 2002-10-08 | 2002-10-09 | 1d |  |  | Project Manager | 8h | 8h |
| 5 | 1.4 | Secure core resources |  | 1d | 2002-10-09 A | 2002-10-10 A | 4 | 100% |  | 2002-10-09 | 2002-10-10 | 1d |  |  | Project Manager | 8h | 8h |
| 6 | 1.5 | Scope complete | milestone | 0d | 2002-10-10 A | 2002-10-10 A | 5 | 100% |  | 2002-10-10 | 2002-10-10 | 0d |  |  |  |  |  |
| 7 | 2 | **Analysis/Software Requirements** |  | 8.5d | 2002-10-10 A | 2002-10-22 |  | 86% | 1.19d | 2002-10-10 | 2002-10-22 | 8.5d | 59d |  |  | 104h | 90h |
| 8 | 2.1 | Conduct needs analysis |  | 2d | 2002-10-10 A | 2002-10-14 A | 6 | 100% |  | 2002-10-10 | 2002-10-14 | 2d |  |  | Analyst | 16h | 16h |
| 9 | 2.2 | Draft preliminary software specifications |  | 3d | 2002-10-14 A | 2002-10-17 A | 8 | 100% |  | 2002-10-14 | 2002-10-17 | 3d |  |  | Analyst | 24h | 24h |
| 10 | 2.3 | Develop preliminary budget |  | 2d | 2002-10-15 A | 2002-10-17 A | 9 | 100% |  | 2002-10-15 | 2002-10-17 | 2d |  |  | Project Manager | 16h | 16h |
| 11 | 2.4 | Review software specifications/budget with team |  | 2h | 2002-10-16 A | 2002-10-16 A | 10 | 100% |  | 2002-10-16 | 2002-10-16 | 2h |  |  | Project Manager; Analyst | 4h | 4h |
| 12 | 2.5 | Incorporate feedback on software specifications |  | 1d | 2002-10-16 A | 2002-10-17 A | 11 | 100% |  | 2002-10-16 | 2002-10-17 | 1d |  |  | Analyst | 8h | 8h |
| 13 | 2.6 | Develop delivery timeline |  | 2d | 2002-10-17 A | 2002-10-21 A | 12 | 100% |  | 2002-10-17 | 2002-10-21 | 2d |  |  | Project Manager | 16h | 16h |
| 14 | 2.7 | Obtain approvals to proceed (concept, timeline, budget) |  | 2h | 2002-10-18 A | 2002-10-18 A | 13 | 100% |  | 2002-10-18 | 2002-10-18 | 2h |  |  | Management; Project Manager | 4h | 4h |
| 15 | 2.8 | Secure required resources |  | 2d | 2002-10-21 A | 2002-10-22 | 14 | 13% | 1.75d | 2002-10-21 | 2002-10-22 | 2d | 59d | 0d | Project Manager | 16h | 2h |
| 16 | 2.9 | Analysis complete | milestone | 0d | 2002-10-22 | 2002-10-22 | 15 |  |  | 2002-10-22 | 2002-10-22 | 0d | 59d | 0d |  |  |  |
| 17 | 3 | **Design** |  | 12d | 2002-10-22 A | 2002-11-06 |  | 88% | 1.5d | 2002-10-22 | 2002-11-06 | 12d | 65d |  |  | 200h | 180h |
| 18 | 3.1 | Review preliminary software specifications |  | 2d | 2002-10-22 A | 2002-10-23 A | 16 | 100% |  | 2002-10-22 | 2002-10-23 | 2d |  |  | Analyst | 16h | 16h |
| 19 | 3.2 | Develop functional specifications |  | 5d | 2002-10-23 A | 2002-10-29 A | 18 | 100% |  | 2002-10-23 | 2002-10-29 | 5d |  |  | Analyst | 40h | 40h |
| 20 | 3.3 | Develop prototype based on functional specifications |  | 4d | 2002-10-25 A | 2002-11-01 | 19 | 38% | 2.5d | 2002-10-25 | 2002-11-01 | 4d | 68d |  | Analyst | 32h | 12h |
| 21 | 3.4 | Review functional specifications |  | 2d | 2002-10-29 A | 2002-10-30 A | 20 | 100% |  | 2002-10-29 | 2002-10-30 | 2d |  |  | Management | 16h | 16h |
| 22 | 3.5 | Incorporate feedback into functional specifications |  | 2d | 2002-10-30 A | 2002-10-31 A | 21 | 100% |  | 2002-10-30 | 2002-10-31 | 2d |  |  | Management | 16h | 16h |
| 23 | 3.6 | Obtain approval to proceed |  | 5d | 2002-10-31 A | 2002-11-06 A | 22 | 100% |  | 2002-10-31 | 2002-11-06 | 5d |  |  | Management; Project Manager | 80h | 80h |
| 24 | 3.7 | Design complete | milestone | 0d | 2002-11-06 | 2002-11-06 | 23 |  |  | 2002-11-06 | 2002-11-06 | 0d | 26d | 0d |  |  |  |

| ID | WBS | Task | Type | Duration | Start | Finish | Predecessors | Complete | Remaining | Baseline start | Baseline finish | Baseline duration | Total slack | Free slack | Resources | Work | Actual work |
| --- | --- | --- | --- | --- | --- | --- | --- | --- | --- | --- | --- | --- | --- | --- | --- | --- | --- |
| 25 | 4 | **Development** |  | 27d | 2002-11-07 A | 2002-12-13 |  | 12% | 23.83d | 2002-11-07 | 2002-12-13 | 27d | 38d |  |  | 344h | 40.4h |
| 26 | 4.1 | Review functional specifications |  | 4d | 2002-11-07 A | 2002-11-12 | 24 | 64% | 1.45d | 2002-11-07 | 2002-11-12 | 4d | 59.5d | 0d | Developer | 32h | 20.4h |
| 27 | 4.2 | Identify modular/tiered design parameters |  | 3d | 2002-11-13 A | 2002-11-15 | 26 | 50% | 1.5d | 2002-11-13 | 2002-11-15 | 3d | 58d |  | Developer | 24h | 12h |
| 28 | 4.3 | Assign development staff |  | 1d | 2002-11-15 A | 2002-11-15 A | 27 | 100% |  | 2002-11-15 | 2002-11-15 | 1d |  |  | Developer | 8h | 8h |
| 29 | 4.4 | Develop code |  | 20d | 2002-11-18 | 2002-12-13 | 28 |  |  | 2002-11-18 | 2002-12-13 | 20d | 0d |  | Developer | 160h |  |
| 30 | 4.5 | Developer testing (primary debugging) |  | 15d | 2002-11-25 | 2002-12-13 | 29FS-7.5% |  |  | 2002-11-25 | 2002-12-13 | 15d | 0d |  | Developer | 120h |  |
| 31 | 4.6 | Development complete | milestone | 0d | 2002-12-13 | 2002-12-13 | 30 |  |  | 2002-12-13 | 2002-12-13 | 0d | 0d |  |  |  |  |
| 32 | 5 | **Testing** |  | 50d | 2002-11-07 | 2003-01-15 |  |  |  | 2002-11-07 | 2003-01-15 | 50d | 15d |  |  | 200h |  |
| 33 | 5.1 | Develop unit test plans using product specifications |  | 1d | 2002-11-07 | 2002-11-07 | 24 |  |  | 2002-11-07 | 2002-11-07 | 1d | 26d |  | Testers | 8h |  |
| 34 | 5.2 | Develop integration test plans using product specifications |  | 1d | 2002-11-07 | 2002-11-07 | 24 |  |  | 2002-11-07 | 2002-11-07 | 1d | 64d |  | Testers | 8h |  |
| 35 | 5.3 | **Unit Testing** |  | 11d | 2002-12-16 | 2002-12-30 |  |  |  | 2002-12-16 | 2002-12-30 | 11d | 0d |  |  | 88h |  |
| 36 | 5.3.1 | Review modular code |  | 2d | 2002-12-16 | 2002-12-17 | 33, 31 |  |  | 2002-12-16 | 2002-12-17 | 2d | 0d |  | Testers | 16h |  |
| 37 | 5.3.2 | Test component modules to product specifications |  | 2d | 2002-12-18 | 2002-12-19 | 31, 36 |  |  | 2002-12-18 | 2002-12-19 | 2d | 0d |  | Testers | 16h |  |
| 38 | 5.3.3 | Identify anomalies to product specifications |  | 2d | 2002-12-20 | 2002-12-23 | 37 |  |  | 2002-12-20 | 2002-12-23 | 2d | 0d |  | Testers | 16h |  |
| 39 | 5.3.4 | Modify code |  | 3d | 2002-12-24 | 2002-12-26 | 38 |  |  | 2002-12-24 | 2002-12-26 | 3d | 0d |  | Testers | 24h |  |
| 40 | 5.3.5 | Re-test modified code |  | 2d | 2002-12-27 | 2002-12-30 | 39 |  |  | 2002-12-27 | 2002-12-30 | 2d | 0d |  | Testers | 16h |  |
| 41 | 5.3.6 | Unit testing complete | milestone | 0d | 2002-12-30 | 2002-12-30 | 40 |  |  | 2002-12-30 | 2002-12-30 | 0d | 0d |  |  |  |  |
| 42 | 5.4 | **Integration Testing** |  | 12d | 2002-12-31 | 2003-01-15 |  |  |  | 2002-12-31 | 2003-01-15 | 12d | 0d |  |  | 96h |  |
| 43 | 5.4.1 | Test module integration |  | 5d | 2002-12-31 | 2003-01-06 | 41 |  |  | 2002-12-31 | 2003-01-06 | 5d | 0d |  | Testers | 40h |  |
| 44 | 5.4.2 | Identify anomalies to specifications |  | 2d | 2003-01-07 | 2003-01-08 | 43 |  |  | 2003-01-07 | 2003-01-08 | 2d | 0d |  | Testers | 16h |  |
| 45 | 5.4.3 | Modify code |  | 3d | 2003-01-09 | 2003-01-13 | 44 |  |  | 2003-01-09 | 2003-01-13 | 3d | 0d |  | Testers | 24h |  |
| 46 | 5.4.4 | Re-test modified code |  | 2d | 2003-01-14 | 2003-01-15 | 45 |  |  | 2003-01-14 | 2003-01-15 | 2d | 0d |  | Testers | 16h |  |
| 47 | 5.4.5 | Integration testing complete | milestone | 0d | 2003-01-15 | 2003-01-15 | 46 |  |  | 2003-01-15 | 2003-01-15 | 0d | 0d |  |  |  |  |
| 48 | 6 | **Training** |  | 35d | 2002-11-07 | 2002-12-25 |  |  |  | 2002-11-07 | 2002-12-25 | 35d | 15d |  |  | 88h |  |
| 49 | 6.1 | Develop training specifications for end users |  | 1d | 2002-11-07 | 2002-11-07 | 24 |  |  | 2002-11-07 | 2002-11-07 | 1d | 41d | 26d | Trainers | 8h |  |
| 50 | 6.2 | Develop training specifications for helpdesk support staff |  | 1d | 2002-11-07 | 2002-11-07 | 24 |  |  | 2002-11-07 | 2002-11-07 | 1d | 41d | 26d | Trainers | 8h |  |
| 51 | 6.3 | Identify training delivery methodology (computer based training, classroom, etc.) |  | 1d | 2002-11-07 | 2002-11-07 | 24 |  |  | 2002-11-07 | 2002-11-07 | 1d | 41d | 26d | Trainers | 8h |  |
| 52 | 6.4 | Develop training materials |  | 1w | 2002-12-16 | 2002-12-20 | 49, 31, 50, 51 |  |  | 2002-12-16 | 2002-12-20 | 1w | 15d | 0d | Trainers | 40h |  |
| 53 | 6.5 | Conduct training usability study |  | 1d | 2002-12-23 | 2002-12-23 | 52 |  |  | 2002-12-23 | 2002-12-23 | 1d | 15d | 0d | Trainers | 8h |  |
| 54 | 6.6 | Finalize training materials |  | 1d | 2002-12-24 | 2002-12-24 | 53 |  |  | 2002-12-24 | 2002-12-24 | 1d | 15d | 0d | Trainers | 8h |  |
| 55 | 6.7 | Develop training delivery mechanism |  | 1d | 2002-12-25 | 2002-12-25 | 54 |  |  | 2002-12-25 | 2002-12-25 | 1d | 15d | 0d | Trainers | 8h |  |
| 56 | 6.8 | Training materials complete | milestone | 0d | 2002-12-25 | 2002-12-25 | 55 |  |  | 2002-12-25 | 2002-12-25 | 0d | 15d |  |  |  |  |

| ID | WBS | Task | Type | Duration | Start | Finish | Predecessors | Baseline start | Baseline finish | Baseline duration | Total slack | Free slack | Resources | Work |
| --- | --- | --- | --- | --- | --- | --- | --- | --- | --- | --- | --- | --- | --- | --- |
| 57 | 7 | **Documentation** |  | 37d | 2002-11-07 | 2002-12-27 |  | 2002-11-07 | 2002-12-27 | 37d | 13d |  |  | 336h |
| 58 | 7.1 | Develop Help specification |  | 1d | 2002-11-07 | 2002-11-07 | 24 | 2002-11-07 | 2002-11-07 | 1d | 29d | 16d | Technical Communicators | 8h |
| 59 | 7.2 | Develop Help system |  | 3w | 2002-12-02 | 2002-12-20 | 58, 29FS-5% | 2002-12-02 | 2002-12-20 | 3w | 13d | 0d | Technical Communicators | 120h |
| 60 | 7.3 | Review Help documentation |  | 3d | 2002-12-23 | 2002-12-25 | 59 | 2002-12-23 | 2002-12-25 | 3d | 13d | 0d | Technical Communicators | 24h |
| 61 | 7.4 | Incorporate Help documentation feedback |  | 2d | 2002-12-26 | 2002-12-27 | 60 | 2002-12-26 | 2002-12-27 | 2d | 13d | 0d | Technical Communicators | 16h |
| 62 | 7.5 | Develop user manuals specifications |  | 2d | 2002-11-07 | 2002-11-08 | 24 | 2002-11-07 | 2002-11-08 | 2d | 29d | 15d | Technical Communicators | 16h |
| 63 | 7.6 | Develop user manuals |  | 3w | 2002-12-02 | 2002-12-20 | 62, 29FS-5% | 2002-12-02 | 2002-12-20 | 3w | 14d | 0d | Technical Communicators | 120h |
| 64 | 7.7 | Review all user documentation |  | 2d | 2002-12-23 | 2002-12-24 | 63 | 2002-12-23 | 2002-12-24 | 2d | 14d | 0d | Technical Communicators | 16h |
| 65 | 7.8 | Incorporate user documentation feedback |  | 2d | 2002-12-25 | 2002-12-26 | 64 | 2002-12-25 | 2002-12-26 | 2d | 14d | 1d | Technical Communicators | 16h |
| 66 | 7.9 | Documentation complete | milestone | 0d | 2002-12-27 | 2002-12-27 | 65, 61 | 2002-12-27 | 2002-12-27 | 0d | 13d |  |  |  |
| 67 | 8 | **Pilot** |  | 68d | 2002-10-23 | 2003-01-24 |  | 2002-10-23 | 2003-01-24 | 68d | 0d |  |  | 64h |
| 68 | 8.1 | Identify test group |  | 1d | 2002-10-23 | 2002-10-23 | 16 | 2002-10-23 | 2002-10-23 | 1d | 59d | 0d | Project Manager | 8h |
| 69 | 8.2 | Develop software delivery mechanism |  | 1d | 2002-10-24 | 2002-10-24 | 68 | 2002-10-24 | 2002-10-24 | 1d | 59d |  |  |  |
| 70 | 8.3 | Install/deploy software |  | 1d | 2003-01-16 | 2003-01-16 | 47, 69, 66, 56 | 2003-01-16 | 2003-01-16 | 1d | 0d |  | Deployment Team | 8h |
| 71 | 8.4 | Obtain user feedback |  | 1w | 2003-01-17 | 2003-01-23 | 70 | 2003-01-17 | 2003-01-23 | 1w | 0d |  | Deployment Team | 40h |
| 72 | 8.5 | Evaluate testing information |  | 1d | 2003-01-24 | 2003-01-24 | 71 | 2003-01-24 | 2003-01-24 | 1d | 0d |  | Deployment Team | 8h |
| 73 | 8.6 | Pilot complete | milestone | 0d | 2003-01-24 | 2003-01-24 | 72 | 2003-01-24 | 2003-01-24 | 0d | 0d |  |  |  |
| 74 | 9 | **Deployment** |  | 5d | 2003-01-27 | 2003-01-31 |  | 2003-01-27 | 2003-01-31 | 5d | 0d |  |  | 40h |
| 75 | 9.1 | Determine final deployment strategy |  | 1d | 2003-01-27 | 2003-01-27 | 73 | 2003-01-27 | 2003-01-27 | 1d | 0d |  | Deployment Team | 8h |
| 76 | 9.2 | Develop deployment methodology |  | 1d | 2003-01-28 | 2003-01-28 | 75 | 2003-01-28 | 2003-01-28 | 1d | 0d |  | Deployment Team | 8h |
| 77 | 9.3 | Secure deployment resources |  | 1d | 2003-01-29 | 2003-01-29 | 76 | 2003-01-29 | 2003-01-29 | 1d | 0d |  | Deployment Team | 8h |
| 78 | 9.4 | Train support staff |  | 1d | 2003-01-30 | 2003-01-30 | 77 | 2003-01-30 | 2003-01-30 | 1d | 0d |  | Deployment Team | 8h |
| 79 | 9.5 | Deploy software |  | 1d | 2003-01-31 | 2003-01-31 | 78 | 2003-01-31 | 2003-01-31 | 1d | 0d |  | Deployment Team | 8h |
| 80 | 9.6 | Deployment complete | milestone | 0d | 2003-01-31 | 2003-01-31 | 79 | 2003-01-31 | 2003-01-31 | 0d | 0d |  |  |  |

| ID | WBS | Task | Type | Duration | Start | Finish | Predecessors | Baseline start | Baseline finish | Baseline duration | Total slack | Resources | Work |
| --- | --- | --- | --- | --- | --- | --- | --- | --- | --- | --- | --- | --- | --- |
| 81 | 10 | **Post Implementation Review** |  | 3d | 2003-02-03 | 2003-02-05 |  | 2003-02-03 | 2003-02-05 | 3d | 0d |  | 24h |
| 82 | 10.1 | Document lessons learned |  | 1d | 2003-02-03 | 2003-02-03 | 80 | 2003-02-03 | 2003-02-03 | 1d | 0d | Project Manager | 8h |
| 83 | 10.2 | Distribute to team members |  | 1d | 2003-02-04 | 2003-02-04 | 82 | 2003-02-04 | 2003-02-04 | 1d | 0d | Project Manager | 8h |
| 84 | 10.3 | Create software maintenance team |  | 1d | 2003-02-05 | 2003-02-05 | 83 | 2003-02-05 | 2003-02-05 | 1d | 0d | Project Manager | 8h |
| 85 | 10.4 | Post implementation review complete | milestone | 0d | 2003-02-05 | 2003-02-05 | 84 | 2003-02-05 | 2003-02-05 | 0d | 0d |  |  |
| 86 | 11 | Software development template complete | milestone | 0d | 2003-02-05 | 2003-02-05 | 85 | 2003-02-05 | 2003-02-05 | 0d | 0d |  |  |
